# ECDL Zarządzanie projektami

How a schedule from MS Project changed from version to version. A marks actual dates.

## Version 1 (saved 2012-03-31, file projektbuddomXY.mpp)

| ID | WBS | Task | Duration | Start | Finish | Predecessors | Total float |
| --- | --- | --- | --- | --- | --- | --- | --- |
| 1 | BU-D1000001 | **etap I stan zerowy** | 22.5d | 2012-03-02 | 2012-04-03 |  | 0d |
| 2 | BU-D1000001-1 | **Zagospodarowanie terenu** | 22d | 2012-03-02 | 2012-04-02 |  | 1.5d |
| 3 |  | niwelacja terenu | 2d | 2012-03-02 | 2012-03-05 |  | 1.5d |
| 4 |  | zagospodarowanie placu terenu | 20d | 2012-03-06 | 2012-04-02 | 3 | 1.5d |
| 5 | BU-D1000001-2 | **Roboty ziemne** | 3.5d | 2012-03-02 | 2012-03-07 |  | 0d |
| 6 |  | wytyczenie obiektu | 0.5d | 2012-03-02 | 2012-03-02 |  | 0d |
| 7 |  | wykopy | 3d | 2012-03-02 | 2012-03-07 | 6 | 0d |
| 8 | BU-D1000001-3 | **Fundamenty** | 17d | 2012-03-07 | 2012-03-30 |  | 0d |
| 9 |  | ściany fundamentowe | 5d | 2012-03-19 | 2012-03-26 | 11FS+3d | 0d |
| 10 |  | instalacje Wod Kan wewnątrz fundamentów | 2d | 2012-03-27 | 2012-03-29 | 9FS+1d | 0d |
| 11 |  | ławy fundamentowe | 5d | 2012-03-07 | 2012-03-14 | 7 | 0d |
| 12 |  | izolacje termiczne I przeciwwilgociowe fundamentów | 2d | 2012-03-28 | 2012-03-30 | 10SS+1d | 0d |
| 13 |  | odbiór etapu I - stanu zerowego | 1d | 2012-04-02 | 2012-04-03 | 12FS+1d | 0d |
| 14 | BU-D1000002 | **etap II stan surowy otwarty** | 152d | 2012-04-04 | 2012-11-02 | 1 | 0d |
| 15 |  | ściany zewnętrzne | 28d | 2012-04-04 | 2012-05-14 | 13FS+1d | 0d |
| 16 |  | wieńce | 6d | 2012-05-14 | 2012-05-22 | 15 | 0d |
| 17 |  | strop parteru | 11d | 2012-05-25 | 2012-06-11 | 16FS+3d | 0d |
| 18 | BU-D1000002-4 | **Posadzki** | 10d | 2012-06-12 | 2012-06-26 |  | 93d |
| 19 |  | podkłady pod posadzki | 5d | 2012-06-12 | 2012-06-19 | 17FS+1d | 93d |
| 20 |  | podłoża - posadzki | 7d | 2012-06-15 | 2012-06-26 | 19SS+3d | 93d |
| 21 | BU-D1000002-5 | **Więźba dachowa** | 101d | 2012-06-14 | 2012-11-02 |  | 0d |
| 22 |  | konstrukcja więźby | 45d | 2012-06-14 | 2012-08-16 | 17FS+3d | 0d |
| 23 |  | pokrycia | 51d | 2012-08-16 | 2012-10-26 | 22 | 0d |
| 24 |  | rynny I rury spustowe | 4d | 2012-10-26 | 2012-11-01 | 23 | 0d |
| 25 |  | odbiór etapu II - stanu surowego otwartego | 1d | 2012-11-01 | 2012-11-02 | 24 | 0d |
| 26 |  | Etap III - stan surowy zamknięty | 2mo | 2012-11-02 | 2012-12-28 | 14 | 0d |
| 27 |  | Etap IV - stan deweloperski | 3mo | 2012-12-28 | 2013-03-22 | 26 | 0d |

## Version 2 (data date 2012-05-21, saved 2012-03-31, file projektbuddomXYwyk.mpp)

Last finish stays 2013-03-22. Complete tasks 0 → 10.

Changed:

| ID | Task | Start | Finish | Duration | Complete | Total float | Other |
| --- | --- | --- | --- | --- | --- | --- | --- |
| 1 | **etap I stan zerowy** | 2012-03-02 A | 2012-04-03 A | 22.5d → 22.38d | 0% → 100% | 0d → none | baseline start none → 2012-03-02; baseline finish none → 2012-04-03 |
| 2 | **Zagospodarowanie terenu** | 2012-03-02 A | 2012-04-02 A | 22d → 21.88d | 0% → 100% | 1.5d → none | baseline start none → 2012-03-02; baseline finish none → 2012-04-02 |
| 3 | niwelacja terenu | 2012-03-02 A | 2012-03-05 A |  | 0% → 100% | 1.5d → none | baseline start none → 2012-03-02; baseline finish none → 2012-03-05 |
| 4 | zagospodarowanie placu terenu | 2012-03-06 A | 2012-04-02 A |  | 0% → 100% | 1.5d → none | baseline start none → 2012-03-06; baseline finish none → 2012-04-02 |
| 5 | **Roboty ziemne** | 2012-03-02 A | 2012-03-07 A | 3.5d → 3.38d | 0% → 100% | 0d → none | baseline start none → 2012-03-02; baseline finish none → 2012-03-07 |
| 6 | wytyczenie obiektu | 2012-03-02 A | 2012-03-02 A |  | 0% → 100% | 0d → none | baseline start none → 2012-03-02; baseline finish none → 2012-03-02 |
| 7 | wykopy | 2012-03-02 A | 2012-03-07 A |  | 0% → 100% | 0d → none | baseline start none → 2012-03-02; baseline finish none → 2012-03-07 |
| 8 | **Fundamenty** | 2012-03-07 A | 2012-03-30 A | 17d → 16.88d | 0% → 100% | 0d → none | baseline start none → 2012-03-07; baseline finish none → 2012-03-30 |
| 9 | ściany fundamentowe | 2012-03-19 A | 2012-03-26 A |  | 0% → 100% | 0d → none | baseline start none → 2012-03-19; baseline finish none → 2012-03-26 |
| 10 | instalacje Wod Kan wewnątrz fundamentów | 2012-03-27 A | 2012-03-29 A |  | 0% → 100% | 0d → none | baseline start none → 2012-03-27; baseline finish none → 2012-03-29 |
| 11 | ławy fundamentowe | 2012-03-07 A | 2012-03-14 A |  | 0% → 100% | 0d → none | baseline start none → 2012-03-07; baseline finish none → 2012-03-14 |
| 12 | izolacje termiczne I przeciwwilgociowe fundamentów | 2012-03-28 A | 2012-03-30 A |  | 0% → 100% | 0d → none | baseline start none → 2012-03-28; baseline finish none → 2012-03-30 |
| 13 | odbiór etapu I - stanu zerowego | 2012-04-02 A | 2012-04-03 A |  | 0% → 100% | 0d → none | baseline start none → 2012-04-02; baseline finish none → 2012-04-03 |
| 14 | **etap II stan surowy otwarty** | 2012-04-04 A |  | 152d → 151.88d | 0% → 21% |  | baseline start none → 2012-04-04; baseline finish none → 2012-11-02 |
| 15 | ściany zewnętrzne | 2012-04-04 A | 2012-05-14 A |  | 0% → 100% | 0d → none | baseline start none → 2012-04-04; baseline finish none → 2012-05-14 |
| 16 | wieńce | 2012-05-14 A |  | 6d → 5.88d | 0% → 77% |  | baseline start none → 2012-05-14; baseline finish none → 2012-05-22 |
| 17 | strop parteru |  |  |  |  |  | baseline start none → 2012-05-25; baseline finish none → 2012-06-11 |
| 18 | **Posadzki** |  |  |  |  |  | baseline start none → 2012-06-12; baseline finish none → 2012-06-26 |
| 19 | podkłady pod posadzki |  |  |  |  |  | baseline start none → 2012-06-12; baseline finish none → 2012-06-19 |
| 20 | podłoża - posadzki |  |  |  |  |  | baseline start none → 2012-06-15; baseline finish none → 2012-06-26 |
| 21 | **Więźba dachowa** |  |  |  |  |  | baseline start none → 2012-06-14; baseline finish none → 2012-11-02 |
| 22 | konstrukcja więźby |  |  |  |  |  | baseline start none → 2012-06-14; baseline finish none → 2012-08-16 |
| 23 | pokrycia |  |  |  |  |  | baseline start none → 2012-08-16; baseline finish none → 2012-10-26 |
| 24 | rynny I rury spustowe |  |  |  |  |  | baseline start none → 2012-10-26; baseline finish none → 2012-11-01 |
| 25 | odbiór etapu II - stanu surowego otwartego |  |  |  |  |  | baseline start none → 2012-11-01; baseline finish none → 2012-11-02 |
| 26 | Etap III - stan surowy zamknięty |  |  |  |  |  | baseline start none → 2012-11-02; baseline finish none → 2012-12-28 |
| 27 | Etap IV - stan deweloperski |  |  |  |  |  | baseline start none → 2012-12-28; baseline finish none → 2013-03-22 |
